# Intervoice Schedule 2024-PRMP-MES-HIE-001-RFP

Schedule from MS Project, 2024-07-01 to 2026-06-30, status date 2024-03-11.

## Calendars

- Standard: Mon-Fri 08:00-12:00, 13:00-17:00; Sat-Sun off.

## Resources

| Resource |
| --- |
| Intervoice |
| CSS/Intervoice |
| Intervoice/CSS |
| CSS |
| All parties |

## Schedule

| ID | WBS | Task | Type | Duration | Start | Finish | Baseline start | Baseline finish | Baseline duration | Total slack | Resources | Work |
| --- | --- | --- | --- | --- | --- | --- | --- | --- | --- | --- | --- | --- |
| 1 | 1 | **HIE Work Plan Draft** |  | 522d | 2024-07-01 | 2026-06-30 | 2024-01-01 | 2026-06-30 | 652d | 0d |  | 192416h |
| 2 | 1.1 | **Deliverable Documents** |  | 522d | 2024-07-01 | 2026-06-30 | 2024-07-01 | 2026-06-30 | 522d | 0d |  | 14784h |
| 3 | 1.1.1 | D01 Monthly Status Report | milestone, manual | 522d | 2024-07-01 | 2026-06-30 | 2024-07-01 | 2026-06-30 | 522d |  | Intervoice | 4176h |
| 4 | 1.1.2 | D02 PRHIE Work Plan | milestone, manual | 23d | 2024-07-01 | 2024-07-31 | 2024-07-01 | 2024-07-31 | 23d |  | CSS/Intervoice | 184h |
| 5 | 1.1.3 | D03 Kickoff Meeting | milestone, manual | 23d | 2024-07-01 | 2024-07-31 | 2024-07-01 | 2024-07-31 | 23d |  | Intervoice/CSS | 184h |
| 6 | 1.1.4 | D04 Implementation Plan | milestone, manual | 66d | 2024-07-01 | 2024-09-30 | 2024-07-01 | 2024-09-30 | 66d |  | CSS/Intervoice | 528h |
| 7 | 1.1.5 | D05 HIE Participation Engagement and Technical Assistance Plan | milestone, manual | 120d | 2024-07-01 | 2024-12-13 | 2024-07-01 | 2024-12-13 | 120d |  | Intervoice | 960h |
| 8 | 1.1.6 | D06 Operations Management Plan | manual | 120d | 2024-07-01 | 2024-12-13 | 2024-07-01 | 2024-12-13 | 120d |  | Intervoice | 960h |
| 9 | 1.1.7 | D07 Security, Privacy, and Confidentiality Plan | manual | 45d | 2024-07-01 | 2024-08-30 | 2024-07-01 | 2024-08-30 | 45d |  | CSS/Intervoice | 360h |
| 10 | 1.1.8 | D08 Staffing Management Plan | manual | 66d | 2024-07-01 | 2024-09-30 | 2024-07-01 | 2024-09-30 | 66d |  | Intervoice/CSS | 528h |
| 11 | 1.1.9 | D09 Incident Management Plan | manual | 45d | 2024-07-01 | 2024-08-30 | 2024-07-01 | 2024-08-30 | 45d |  | CSS/Intervoice | 360h |
| 12 | 1.1.10 | D10 Training Readiness Plan | manual | 78d | 2024-08-15 | 2024-11-30 | 2024-08-15 | 2024-11-30 | 78d |  | Intervoice/CSS | 624h |
| 13 | 1.1.11 | D11 Data Management Plan | manual | 132d | 2024-07-01 | 2024-12-31 | 2024-07-01 | 2024-12-31 | 132d |  | CSS/Intervoice | 1056h |
| 14 | 1.1.12 | D12 Disaster Recovery and Business Continuity Plan | manual | 66d | 2024-07-01 | 2024-09-30 | 2024-07-01 | 2024-09-30 | 66d |  | CSS/Intervoice | 528h |
| 15 | 1.1.13 | D13 Public Health Systems Plan | manual | 34d | 2024-08-15 | 2024-10-01 | 2024-08-15 | 2024-10-01 | 34d |  | CSS/Intervoice | 272h |
| 16 | 1.1.14 | D14 Pilot Implementation Plans | manual | 45d | 2024-07-01 | 2024-08-30 | 2024-07-01 | 2024-08-30 | 45d |  | CSS | 360h |
| 17 | 1.1.15 | D15 Data Transition Plan | manual | 45d | 2024-07-01 | 2024-08-30 | 2024-07-01 | 2024-08-30 | 45d |  | CSS | 360h |
| 18 | 1.1.16 | D16 Detailed System Design Document | manual | 66d | 2024-07-01 | 2024-09-30 | 2024-07-01 | 2024-09-30 | 66d |  | CSS | 528h |
| 19 | 1.1.17 | D17 Independent, Third-Party Security, and Privacy Controls Assessment Report | manual | 132d | 2024-07-01 | 2024-12-31 | 2024-07-01 | 2024-12-31 | 132d |  | CSS/Intervoice | 1056h |
| 20 | 1.1.18 | D18 Outcomes Based Certification (OBC) Support Plan and Reporting | manual | 133d | 2024-08-01 | 2025-02-01 | 2024-08-01 | 2025-02-01 | 133d |  | CSS | 1064h |
| 21 | 1.1.19 | D19 Turnover and Closeout Management Plan | manual | 87d | 2024-07-01 | 2024-10-29 | 2024-07-01 | 2024-10-29 | 87d |  | Intervoice/CSS | 696h |
| 22 | 1.2 | **1. HIE Scope of Work: Enterprise Identity Services** |  | 522d | 2024-07-01 | 2026-06-30 | 2024-01-01 | 2026-06-30 | 652d | 0d |  | 12248h |
| 23 | 1.2.1 | 1.1 Establish Reporting Metrics | manual | 46d | 2024-07-01 | 2024-08-31 | 2024-07-01 | 2024-08-31 | 46d |  | All parties | 368h |
| 24 | 1.2.2 | **1.2 Master Patient Index (MPI)** |  | 11d | 2024-07-01 | 2024-07-15 | 2024-07-01 | 2024-07-15 | 11d |  | CSS | 8984h |
| 25 | 1.2.2.1 | 1.2.1 Deploy MPI | manual | 11d | 2024-07-01 | 2024-07-15 | 2024-07-01 | 2024-07-15 | 11d |  | CSS | 88h |
| 26 | 1.2.2.2 | 1.2.2 Add new participant source codes and feeds to MPI | manual | 522d | 2024-07-01 | 2026-06-30 | 2024-07-01 | 2026-06-30 | 522d |  | CSS | 4176h |
| 27 | 1.2.2.3 | 1.2.3 Update referential data sources | manual | 522d | 2024-07-01 | 2026-06-30 | 2024-07-01 | 2026-06-30 | 522d |  | CSS | 4176h |
| 28 | 1.2.2.4 | 1.2.4 Perform data quality analysis to improve matching | manual | 13d | 2024-12-13 | 2024-12-31 | 2024-12-13 | 2024-12-31 | 13d |  | CSS | 104h |
| 29 | 1.2.2.5 | 1.2.5 Integrate any existing ADT data | manual | 44d | 2024-08-15 | 2024-10-15 | 2024-08-15 | 2024-10-15 | 44d |  | CSS | 352h |

| ID | WBS | Task | Type | Duration | Start | Finish | Baseline start | Baseline finish | Baseline duration | Total slack | Resources | Work |
| --- | --- | --- | --- | --- | --- | --- | --- | --- | --- | --- | --- | --- |
| 30 | 1.2.3 | **1.3 Master Provider Registry (MPR)** |  | 44d | 2024-08-15 | 2024-10-15 | 2024-08-15 | 2024-10-15 | 44d |  | CSS | 2896h |
| 31 | 1.2.3.1 | 1.3.1 Deploy MPR | manual | 13d | 2024-10-15 | 2024-10-31 | 2024-10-15 | 2024-10-31 | 13d |  | CSS | 104h |
| 32 | 1.2.3.2 | 1.3.2 Add PR sources of provider information to improve matching | manual | 43d | 2024-11-01 | 2024-12-31 | 2024-11-01 | 2024-12-31 | 43d |  | CSS | 344h |
| 33 | 1.2.3.3 | 1.3.3 Perform data quality analysis to improve matching | manual | 262d | 2024-11-01 | 2025-11-03 | 2024-01-01 | 2024-12-31 | 262d |  | CSS | 2096h |
| 34 | 1.3 | **2. HIE Scope of Work: Provider Portal Service** |  | 522d | 2024-07-01 | 2026-06-30 | 2024-07-01 | 2026-06-30 | 522d | 0d |  | 24960h |
| 35 | 1.3.1 | 2.1 Establish Reporting Metrics | manual | 34d | 2024-07-01 | 2024-08-15 | 2024-07-01 | 2024-08-15 | 34d |  | All parties | 272h |
| 36 | 1.3.2 | 2.2 Onboard new HIE participants | manual | 261d | 2024-07-01 | 2025-06-30 | 2024-07-01 | 2025-06-30 | 261d |  | Intervoice/CSS | 2088h |
| 37 | 1.3.3 | **2.3 Web-Based Provider Portal** |  | 56d | 2024-07-01 | 2024-09-15 | 2024-07-01 | 2024-09-15 | 56d |  | CSS | 1344h |
| 38 | 1.3.3.1 | 2.3.1 Deploy web-based portal | manual | 56d | 2024-07-01 | 2024-09-15 | 2024-07-01 | 2024-09-15 | 56d |  | CSS | 448h |
| 39 | 1.3.3.2 | 2.3.2 Provide role-based access to users for new HIE participants | manual | 56d | 2024-07-01 | 2024-09-15 | 2024-07-01 | 2024-09-15 | 56d |  | CSS | 448h |
| 40 | 1.3.4 | **2.4 SMART on FHIR Provider Portal** |  | 121d | 2024-07-01 | 2024-12-15 | 2024-07-01 | 2024-12-15 | 121d |  | CSS | 16968h |
| 41 | 1.3.4.1 | 2.4.1 Deploy SMART on FHIR app to EHRs capable of technology | manual | 522d | 2024-07-01 | 2026-06-30 | 2024-07-01 | 2026-06-30 | 522d |  | CSS | 4176h |
| 42 | 1.3.4.2 | **2.4.2 Identify EHRs for integration of HIE data into workflow** |  | 522d | 2024-07-01 | 2026-06-30 | 2024-07-01 | 2026-06-30 | 522d |  | CSS/Intervoice | 11824h |
| 43 | 1.3.4.2.1 | 2.4.2.1 Work with participants to download SMART on FHIR integrations within native EHR | manual | 478d | 2024-08-30 | 2026-06-30 | 2024-08-30 | 2026-06-30 | 478d |  | CSS/Intervoice | 3824h |
| 44 | 1.3.4.2.2 | 2.4.2.2 Deploy SMART on FHIR app via other integration methods | manual | 478d | 2024-08-30 | 2026-06-30 | 2024-08-30 | 2026-06-30 | 478d |  | CSS | 3824h |
| 45 | 1.3.5 | **2.5 Update provider portal functionality and alerts** |  | 54d | 2024-08-01 | 2024-10-15 | 2024-08-01 | 2024-10-15 | 54d |  | CSS | 4288h |
| 46 | 1.3.5.1 | 2.5.1.Display CCDs in portal (via participants) | manual | 44d | 2024-08-15 | 2024-10-15 | 2024-08-15 | 2024-10-15 | 44d |  | CSS | 352h |
| 47 | 1.3.5.2 | 2.5.2 Identify USCDI data elements needing discrete portal displays | manual | 88d | 2024-09-01 | 2024-12-31 | 2024-09-01 | 2024-12-31 | 88d |  | CSS | 704h |
| 48 | 1.3.5.3 | 2.5.3 Update portal to display discrete USCDI data elements (via CCDs or FHIR) as needed | manual | 88d | 2024-09-01 | 2024-12-31 | 2024-09-01 | 2024-12-31 | 88d |  | CSS | 704h |
| 49 | 1.3.5.4 | 2.5.4 Identify gaps in care use cases for display within portal | manual | 65d | 2025-01-01 | 2025-04-01 | 2025-01-01 | 2025-04-01 | 65d |  | CSS | 520h |
| 50 | 1.3.5.5 | 2.5.5 Configure gaps in care alerts to display within portal | manual | 197d | 2025-04-01 | 2025-12-31 | 2025-04-01 | 2025-12-31 | 197d |  | CSS | 1576h |
| 51 | 1.4 | **3. HIE Scope of Work: CEND Notification and Alert Services** |  | 499d | 2024-08-01 | 2026-06-30 | 2024-08-01 | 2026-06-30 | 499d | 0d |  | 16152h |
| 52 | 1.4.1 | 3.1 Establish Reporting Metrics | manual | 23d | 2024-08-01 | 2024-08-31 | 2024-08-01 | 2024-08-31 | 23d |  | All parties | 184h |
| 53 | 1.4.2 | 3.2 Onboard new participants | manual | 499d | 2024-08-01 | 2026-06-30 | 2024-08-01 | 2026-06-30 | 499d |  | CSS | 3992h |
| 54 | 1.4.3 | 3.3 Configure new rules logic for specific notification use cases | manual | 499d | 2024-08-01 | 2026-06-30 | 2024-08-01 | 2026-06-30 | 499d |  | CSS | 3992h |
| 55 | 1.4.4 | 3.4 Route and map new data sources into Notification Service | manual | 499d | 2024-08-01 | 2026-06-30 | 2024-08-01 | 2026-06-30 | 499d |  | CSS | 3992h |
| 56 | 1.4.5 | 3.5 Add alerts to alert database for display at point of care | manual | 499d | 2024-08-01 | 2026-06-30 | 2024-08-01 | 2026-06-30 | 499d |  | CSS | 3992h |

| ID | WBS | Task | Type | Duration | Start | Finish | Baseline start | Baseline finish | Baseline duration | Total slack | Resources | Work |
| --- | --- | --- | --- | --- | --- | --- | --- | --- | --- | --- | --- | --- |
| 57 | 1.5 | **4. HIE Scope of Work: Data Quality and Reporting Services** |  | 499d | 2024-08-01 | 2026-06-30 | 2024-08-01 | 2026-06-30 | 499d | 0d |  | 39920h |
| 58 | 1.5.1 | 4.1 Establish data lake architecture | manual | 499d | 2024-08-01 | 2026-06-30 | 2024-08-01 | 2026-06-30 | 499d |  | All parties | 3992h |
| 59 | 1.5.2 | 4.2 Establish remaining reporting metrics and automate output | manual | 499d | 2024-08-01 | 2026-06-30 | 2024-08-01 | 2026-06-30 | 499d |  | CSS | 3992h |
| 60 | 1.5.3 | 4.3 Parse CCDs, store discrete elements within respective database | manual | 499d | 2024-08-01 | 2026-06-30 | 2024-08-01 | 2026-06-30 | 499d |  | CSS | 3992h |
| 61 | 1.5.4 | 4.4 Identify data as a service needs | manual | 499d | 2024-08-01 | 2026-06-30 | 2024-08-01 | 2026-06-30 | 499d |  | CSS | 3992h |
| 62 | 1.5.5 | 4.5 Bring in new datasets | manual | 499d | 2024-08-01 | 2026-06-30 | 2024-08-01 | 2026-06-30 | 499d |  | CSS | 3992h |
| 63 | 1.5.6 | 4.6 Establish connections to new databases or reference datasets | manual | 499d | 2024-08-01 | 2026-06-30 | 2024-08-01 | 2026-06-30 | 499d |  | CSS | 3992h |
| 64 | 1.5.7 | 4.7 Normalize, standardize, master, translate data | manual | 499d | 2024-08-01 | 2026-06-30 | 2024-08-01 | 2026-06-30 | 499d |  | CSS | 3992h |
| 65 | 1.5.8 | 4.8 Create new analytic reports for delivery | manual | 499d | 2024-08-01 | 2026-06-30 | 2024-08-01 | 2026-06-30 | 499d |  | CSS | 3992h |
| 66 | 1.5.9 | 4.9 Configure rules for delivery | manual | 499d | 2024-08-01 | 2026-06-30 | 2024-08-01 | 2026-06-30 | 499d |  | CSS | 3992h |
| 67 | 1.5.10 | 4.10 Create new dashboards | manual | 499d | 2024-08-01 | 2026-06-30 | 2024-08-01 | 2026-06-30 | 499d |  | CSS | 3992h |
| 68 | 1.6 | **5. HIE Scope of Work: Care Coordination Information Services** |  | 499d | 2024-08-01 | 2026-06-30 | 2024-08-01 | 2026-06-30 | 499d | 0d |  | 40376h |
| 69 | 1.6.1 | 5.1 Establish Reporting Metrics | manual | 33d | 2024-08-01 | 2024-09-15 | 2024-08-01 | 2024-09-15 | 33d |  | All parties | 264h |
| 70 | 1.6.2 | **5.2 CCD Services** |  | 33d | 2024-08-01 | 2024-09-15 | 2024-08-01 | 2024-09-15 | 33d |  | CSS | 10784h |
| 71 | 1.6.2.1 | 5.2.1 CCD Services Onboard new CCD feeds and complete validation | manual | 33d | 2024-08-01 | 2024-09-15 | 2024-08-01 | 2024-09-15 | 33d |  | CSS | 264h |
| 72 | 1.6.2.2 | 5.2.2 Complete any specific CCD translations or configurations | manual | 499d | 2024-08-01 | 2026-06-30 | 2024-08-01 | 2026-06-30 | 499d |  | CSS | 3992h |
| 73 | 1.6.2.3 | 5.2.3 Establish additional national network connectivity | manual | 261d | 2025-01-01 | 2025-12-31 | 2025-01-01 | 2025-12-31 | 261d |  | CSS | 2088h |
| 74 | 1.6.2.4 | 5.2.4 Perform data quality analysis on CCD | manual | 261d | 2025-01-01 | 2025-12-31 | 2025-01-01 | 2025-12-31 | 261d |  | CSS | 2088h |
| 75 | 1.6.2.5 | 5.2.5 Support participants w/ CCD data quality improvement efforts | manual | 261d | 2025-01-01 | 2025-12-31 | 2025-01-01 | 2025-12-31 | 261d |  | CSS | 2088h |
| 76 | 1.6.3 | **5.3 Longitudinal Health Record** |  | 9d | 2024-09-15 | 2024-09-25 | 2024-09-15 | 2024-09-25 | 9d |  | CSS | 88h |
| 77 | 1.6.3.1 | 5.3.1 Display longitudinal health record at the point of care | manual | 2d | 2024-09-25 | 2024-09-26 | 2024-09-25 | 2024-09-26 | 2d |  | CSS | 16h |
| 78 | 1.6.4 | **5.4 Closed Loop Referral Service** |  | 44d | 2025-01-01 | 2025-03-01 | 2025-01-01 | 2025-03-01 | 44d |  | CSS | 6376h |
| 79 | 1.6.4.1 | 5.4.1 Identify referral tool use cases, integration needs, participants | manual | 44d | 2024-11-01 | 2025-01-01 | 2024-11-01 | 2025-01-01 | 44d |  | CSS | 352h |
| 80 | 1.6.4.2 | 5.4.2 Configure referral tool for use case(s) | manual | 44d | 2025-01-01 | 2025-03-01 | 2025-01-01 | 2025-03-01 | 44d |  | CSS | 352h |
| 81 | 1.6.4.3 | 5.4.3 Deploy referral tool in PR | manual | 11d | 2025-04-01 | 2025-04-15 | 2025-04-01 | 2025-04-15 | 11d |  | CSS | 88h |
| 82 | 1.6.4.4 | 5.4.4 Perform any integrations with participants | manual | 316d | 2025-04-15 | 2026-06-30 | 2025-04-15 | 2026-06-30 | 316d |  | CSS | 2528h |
| 83 | 1.6.4.5 | 5.4.5 Onboard participants to use referral tool | manual | 338d | 2025-03-15 | 2026-06-30 | 2025-03-15 | 2026-06-30 | 338d |  | Intervoice/CSS | 2704h |

| ID | WBS | Task | Type | Duration | Start | Finish | Baseline start | Baseline finish | Baseline duration | Total slack | Resources | Work |
| --- | --- | --- | --- | --- | --- | --- | --- | --- | --- | --- | --- | --- |
| 84 | 1.6.5 | **5.5 Consent Management** |  | 446d | 2024-10-15 | 2026-06-30 | 2024-10-15 | 2026-06-30 | 446d |  | CSS | 3832h |
| 85 | 1.6.5.1 | 5.5.1 Establish global opt-out consent management | manual | 11d | 2025-08-01 | 2025-08-15 | 2025-08-01 | 2025-08-15 | 11d |  | Intervoice/CSS | 88h |
| 86 | 1.6.5.2 | 5.5.2 Establish granular consent management | manual | 11d | 2025-08-01 | 2025-08-15 | 2025-08-01 | 2025-08-15 | 11d |  | CSS | 88h |
| 87 | 1.6.5.3 | 5.5.3 Configure additional granular consents | manual | 11d | 2025-08-01 | 2025-08-15 | 2025-08-01 | 2025-08-15 | 11d |  | CSS | 88h |
| 88 | 1.6.6 | **5.6 Social Determinants of Health Integration** |  | 197d | 2025-04-01 | 2025-12-31 | 2025-04-01 | 2025-12-31 | 197d |  | Intervoice/CSS | 11328h |
| 89 | 1.6.6.1 | 5.6.1 Identify SDOH use cases, integration needs, and participants | manual | 129d | 2025-01-01 | 2025-06-30 | 2025-01-01 | 2025-06-30 | 129d |  | All parties | 1032h |
| 90 | 1.6.6.2 | 5.6.2 Establish connections for SDOH data (e.g. HMIS, CBOs, resource directories) | manual | 283d | 2025-06-01 | 2026-06-30 | 2025-06-01 | 2026-06-30 | 283d |  | CSS | 2264h |
| 91 | 1.6.6.3 | 5.6.3 Complete SDOH data configurations (e.g. screening normalizations, z-codes) | manual | 283d | 2025-06-01 | 2026-06-30 | 2025-06-01 | 2026-06-30 | 283d |  | CSS | 2264h |
| 92 | 1.6.6.4 | 5.6.4 Perform any integrations with participants | manual | 283d | 2025-06-01 | 2026-06-30 | 2025-06-01 | 2026-06-30 | 283d |  | CSS | 2264h |
| 93 | 1.6.6.5 | 5.6.5 Update users to view SDOH data and infrastructure | manual | 241d | 2025-07-01 | 2026-06-02 | 2025-07-01 | 2026-06-02 | 241d |  | CSS | 1928h |
| 94 | 1.6.7 | **5.7 Care Team Identification** |  | 459d | 2024-09-26 | 2026-06-30 | 2024-09-26 | 2026-06-30 | 459d |  | CSS | 7704h |
| 95 | 1.6.7.1 | 5.7.1 Deploy care team information in provider portal | manual | 48d | 2024-09-26 | 2024-11-30 | 2024-09-26 | 2024-11-30 | 48d |  | CSS | 384h |
| 96 | 1.6.7.2 | 5.7.2 Add additional sources of patient/participant or patient/provider attribution to Relationship Management Service | manual | 456d | 2024-10-01 | 2026-06-30 | 2024-10-01 | 2026-06-30 | 456d |  | CSS | 3648h |
| 97 | 1.7 | **6. HIE Scope of Work: Public Health Reporting Service** |  | 110d | 2024-09-01 | 2025-01-31 | 2024-09-01 | 2025-01-31 | 110d | 0d |  | 928h |
| 98 | 1.7.1 | 6.1 Establish Reporting Metrics | manual | 24d | 2024-10-01 | 2024-11-01 | 2024-10-01 | 2024-11-01 | 24d |  | CSS | 192h |
| 99 | 1.7.2 | 6.2 Identify new public health feeds that will flow through HIE | manual | 46d | 2024-09-01 | 2024-11-01 | 2024-09-01 | 2024-11-01 | 46d |  | CSS | 368h |
| 100 | 1.7.3 | 6.3 Establish public health feeds to flow through HIE | manual | 23d | 2024-12-01 | 2024-12-31 | 2024-12-01 | 2024-12-31 | 23d |  | CSS | 184h |
| 101 | 1.7.4 | 6.4 Establish automated monitoring of public health feeds | manual | 23d | 2025-01-01 | 2025-01-31 | 2025-01-01 | 2025-01-31 | 23d |  | CSS | 184h |
| 102 | 1.8 | **7. HIE Scope of Work: Medicaid Services** |  | 456d | 2024-10-01 | 2026-06-30 | 2024-10-01 | 2026-06-30 | 456d | 0d |  | 11944h |
| 103 | 1.8.1 | **7.2 CCD Services** |  | 456d | 2024-10-01 | 2026-06-30 | 2024-10-01 | 2026-06-30 | 456d |  | CSS | 11944h |
| 104 | 1.8.1.1 | 7.2.1 CCD Services Onboard new CCD feeds and complete validation | manual | 456d | 2024-10-01 | 2026-06-30 | 2024-10-01 | 2026-06-30 | 456d |  | CSS | 3648h |
| 105 | 1.8.1.2 | 7.2.2 Complete any specific CCD translations or configurations | manual | 45d | 2024-10-15 | 2024-12-15 | 2024-10-15 | 2024-12-15 | 45d |  | CSS | 360h |
| 106 | 1.8.1.3 | 7.2.4 Perform data quality analysis on CCD | manual | 45d | 2024-10-15 | 2024-12-15 | 2024-10-15 | 2024-12-15 | 45d |  | CSS | 360h |
| 107 | 1.8.1.4 | 7.2.5 Support participants w/ CCD data quality improvement efforts | manual | 446d | 2024-10-15 | 2026-06-30 | 2024-10-15 | 2026-06-30 | 446d |  | CSS | 3568h |
| 108 | 1.8.1.5 | 7.2.6 Connect MCO pilot (testing data access) | manual | 45d | 2024-10-15 | 2024-12-15 | 2024-10-15 | 2024-12-15 | 45d |  | CSS | 360h |

| ID | WBS | Task | Type | Duration | Start | Finish | Baseline start | Baseline finish | Baseline duration | Total slack | Resources | Work |
| --- | --- | --- | --- | --- | --- | --- | --- | --- | --- | --- | --- | --- |
| 109 | 1.9 | **8. HIE Scope of Work: DSM Service** |  | 499d | 2024-08-01 | 2026-06-30 | 2024-08-01 | 2026-06-30 | 499d | 0d |  | 11400h |
| 110 | 1.9.1 | 8.1 Establish Reporting Metrics | manual | 23d | 2024-08-01 | 2024-08-31 | 2024-08-01 | 2024-08-31 | 23d |  | All parties | 184h |
| 111 | 1.9.2 | 8.2 Create new accounts | manual | 478d | 2024-09-01 | 2026-06-30 | 2024-09-01 | 2026-06-30 | 478d |  | CSS | 3824h |
| 112 | 1.9.3 | 8.3 Discontinue unused accounts | manual | 478d | 2024-09-01 | 2026-06-30 | 2024-09-01 | 2026-06-30 | 478d |  | CSS | 3824h |
| 113 | 1.9.4 | 8.4 Route CCDs to DSM service | manual | 446d | 2024-10-15 | 2026-06-30 | 2024-10-15 | 2026-06-30 | 446d |  | CSS | 3568h |
| 114 | 1.10 | **9. HIE Scope of Work: Emergency Response Services** |  | 456d | 2024-10-01 | 2026-06-30 | 2024-10-01 | 2026-06-30 | 456d | 0d |  | 12472h |
| 115 | 1.10.1 | 9.1 Establish Reporting Metrics | manual | 24d | 2024-10-01 | 2024-11-01 | 2024-10-01 | 2024-11-01 | 24d |  | All parties | 192h |
| 116 | 1.10.2 | **9.2 EMS Integration** |  | 87d | 2024-12-01 | 2025-03-31 | 2024-12-01 | 2025-03-31 | 87d |  | CSS | 6064h |
| 117 | 1.10.2.1 | 9.2.1 Identify EMS participants willing to share data | manual | 413d | 2024-12-01 | 2026-06-30 | 2024-12-01 | 2026-06-30 | 413d |  | CSS | 3304h |
| 118 | 1.10.2.2 | 9.2.3 Establish connectivity including data translation as needed | manual | 129d | 2025-01-01 | 2025-06-30 | 2025-01-01 | 2025-06-30 | 129d |  | CSS | 1032h |
| 119 | 1.10.2.3 | 9.2.4 Deploy logic needed to support encounter notification services | manual | 129d | 2025-01-01 | 2025-06-30 | 2025-01-01 | 2025-06-30 | 129d |  | CSS | 1032h |
| 120 | 1.10.3 | **9.3 Create connectivity with local health departments as needed** |  | 129d | 2025-01-01 | 2025-06-30 | 2025-01-01 | 2025-06-30 | 129d |  | CSS | 6216h |
| 121 | 1.10.3.1 | 9.3.1 Enable EMS based overdose alerts for care team members | manual | 129d | 2025-01-01 | 2025-06-30 | 2025-01-01 | 2025-06-30 | 129d |  | CSS | 1032h |
| 122 | 1.10.3.2 | 9.3.3 Integrate EMS run sheets into participating EMRs | manual | 129d | 2025-01-01 | 2025-06-30 | 2025-01-01 | 2025-06-30 | 129d |  | CSS | 1032h |
| 123 | 1.10.3.3 | 9.3.4 Perform data quality analysis on data received | manual | 390d | 2025-01-01 | 2026-06-30 | 2025-01-01 | 2026-06-30 | 390d |  | CSS | 3120h |
| 124 | 1.11 | **10. HIE Scope of Work: Interoperability Compliance** |  | 132d | 2024-07-01 | 2024-12-31 | 2024-07-01 | 2024-12-31 | 132d | 0d |  | 7232h |
| 125 | 1.11.1 | 10.1 Establish Reporting Metrics | manual | 46d | 2024-07-01 | 2024-08-31 | 2024-07-01 | 2024-08-31 | 46d |  | All parties | 368h |
| 126 | 1.11.2 | 10.2 Identify EHR integrations and type of integration (HIE data within EHR, exchange of data via feeds, etc.) | manual | 66d | 2024-07-01 | 2024-09-30 | 2024-07-01 | 2024-09-30 | 66d |  | CSS | 528h |
| 127 | 1.11.3 | 10.3.Establish feed connections with EHRs | manual | 132d | 2024-07-01 | 2024-12-31 | 2024-07-01 | 2024-12-31 | 132d |  | CSS | 1056h |
| 128 | 1.11.4 | 10.4.Establish integrations with EHRs | manual | 132d | 2024-07-01 | 2024-12-31 | 2024-07-01 | 2024-12-31 | 132d |  | CSS | 1056h |
| 129 | 1.11.5 | 10.5 Establish data exchange processes with other HIT systems | manual | 132d | 2024-07-01 | 2024-12-31 | 2024-07-01 | 2024-12-31 | 132d |  | CSS | 1056h |
| 130 | 1.11.6 | 10.6 Establish integrations with other HIT systems (e.g. public health, state systems, CBOs) | manual | 132d | 2024-07-01 | 2024-12-31 | 2024-07-01 | 2024-12-31 | 132d |  | CSS | 1056h |
| 131 | 1.11.7 | 10.7 Establish automated monitoring of any data connections | manual | 132d | 2024-07-01 | 2024-12-31 | 2024-07-01 | 2024-12-31 | 132d |  | CSS | 1056h |
| 132 | 1.11.8 | 10.8 Establish SSO into any additional systems (e.g. state eligibility system) | manual | 132d | 2024-07-01 | 2024-12-31 | 2024-07-01 | 2024-12-31 | 132d |  | CSS | 1056h |
